# Ext-Cond-Planning-v01

Schedule from MS Project, 2015-10-01 to 2017-03-01, A marks actual dates.
CERN

## Calendars

- Standard: Mon-Fri 08:00-12:00, 13:00-17:00; Sat-Sun off. Exceptions (off unless hours are given): 2015-12-19 to 2016-01-03 (Chrismas break), 2016-02-15 to 2016-02-21 (leave 1), 2016-03-25 to 2016-04-01 (leave 2), 2016-07-18 to 2016-08-07 (leave 3), 2016-10-10 to 2016-10-16 (leave 4).

## Resources

| Resource |
| --- |
| Denia Bouhired |
| Central design office |
| Section BE-CO-HT |
| Supplier |

## Schedule

| ID | WBS | Task | Type | Duration | Start | Finish | Predecessors | Complete | Remaining | Total slack | Free slack | Constraint | Resources | Work |
| --- | --- | --- | --- | --- | --- | --- | --- | --- | --- | --- | --- | --- | --- | --- |
| 2 | 1 | **Background, research and planning phase** |  | 64d | 2015-10-01 A | 2016-01-12 |  | 39% | 38.72d | 265d |  |  |  | 40h |
| 3 | 1.1 | Study current external conditions system and relevant system components | manual | 0.85mo | 2015-10-01 A | 2015-10-23 A |  | 100% |  |  |  | finish no earlier than 2015-10-23 |  |  |
| 4 | 1.2 | VHDL training | manual | 5d | 2015-10-26 A | 2015-10-30 A | 3 | 100% |  |  |  |  |  |  |
| 5 | 1.3 | Project planning, online documentation (Wiki) |  | 7d | 2015-11-02 A | 2015-11-10 | 4 | 75% | 1.75d | 1d | 0d | finish no earlier than 2015-11-10 |  |  |
| 6 | 1.4 | Survey external conditions |  | 3d | 2015-11-11 | 2015-11-13 | 5 |  |  | 1d | 0d | finish no earlier than 2015-11-13 |  |  |
| 7 | 1.5 | Fail safe operation |  | 5d | 2015-11-16 | 2015-11-20 | 6 |  |  | 1d | 0d |  | Denia Bouhired | 40h |
| 8 | 1.6 | Detailed functional specification |  | 15d | 2015-11-23 | 2015-12-11 | 7 |  |  | 1d | 0d |  |  |  |
| 9 | 1.7 | Section wide review period |  | 12d | 2015-12-14 | 2016-01-12 | 8 |  |  | 1d | 0d |  |  |  |
| 10 | 1.8 | Prepare presentation and schematics phase |  | 5d | 2015-12-14 | 2015-12-18 | 8 |  |  | 272d |  |  |  |  |
| 11 | 2 | **Electronic design phase** |  | 97d | 2016-01-04 | 2016-06-01 |  |  |  | 0d |  |  |  |  |
| 12 | 2.1 | Select possible components | manual | 15d | 2016-01-04 | 2016-01-22 |  |  |  |  |  | start no earlier than 2016-01-04 |  |  |
| 13 | 2.2 | Section meeting | milestone | 0d | 2016-01-12 | 2016-01-12 | 9 |  |  | 1d | 0d |  |  |  |
| 14 | 2.3 | Order components | milestone | 0d | 2016-01-22 | 2016-01-22 | 12 |  |  | 0d |  |  |  |  |
| 15 | 2.4 | Components order with supplier |  | 10w | 2016-01-25 | 2016-04-18 | 14 |  |  | 62d | 0d |  |  |  |
| 16 | 2.5 | Component symbol creation from design office |  | 7d | 2016-01-25 | 2016-02-02 | 14 |  |  | 0d |  | start no earlier than 2016-01-25 |  |  |
| 17 | 2.6 | Follow up to section meeting |  | 14d | 2016-01-13 | 2016-02-01 | 13 |  |  | 1d |  |  |  |  |
| 18 | 2.7 | Draw schematics |  | 15d | 2016-02-03 | 2016-03-01 | 12, 16, 13, 17 |  |  | 0d |  | start no earlier than 2016-01-26 |  |  |
| 19 | 2.8 | Review and modification of schematics |  | 10d | 2016-03-02 | 2016-03-15 | 18 |  |  | 0d |  |  |  |  |
| 20 | 2.9 | Documentation and wiki updates |  | 10d | 2016-03-02 | 2016-03-15 | 18 |  |  | 225d |  | start no earlier than 2016-03-02 |  |  |
| 21 | 2.10 | Implement suggested changes |  | 1w | 2016-03-16 | 2016-03-22 | 19 |  |  | 0d |  |  |  |  |
| 22 | 2.11 | Send schematics to design office | milestone | 0d | 2016-03-22 | 2016-03-22 | 21 |  |  | 0d |  |  |  |  |
| 23 | 2.12 | Awaiting layout from design office |  | 6w | 2016-03-23 | 2016-05-11 | 22 |  |  | 10d | 0d |  |  |  |
| 24 | 2.13 | Receive layout from design office | milestone | 0d | 2016-05-11 | 2016-05-11 | 23, 22 |  |  | 10d | 0d |  |  |  |
| 25 | 2.14 | Section wide review of layout |  | 5d | 2016-05-12 | 2016-05-18 | 24 |  |  | 10d | 0d |  |  |  |
| 26 | 2.15 | Review and modification of layout |  | 2w | 2016-05-19 | 2016-06-01 | 25 |  |  | 10d | 0d |  |  |  |

Notes:
- 19: By the section and by myself

| ID | WBS | Task | Type | Duration | Start | Finish | Predecessors | Total slack | Free slack |
| --- | --- | --- | --- | --- | --- | --- | --- | --- | --- |
| 27 | 3 | **Gateware development** |  | 90d | 2016-03-23 | 2016-08-24 |  | 0d |  |
| 28 | 3.1 | Learn tool usage and setup environment |  | 5d | 2016-03-23 | 2016-04-06 | 22 | 0d |  |
| 29 | 3.2 | RTM - SVEC communication |  | 15d | 2016-04-07 | 2016-04-27 | 28 | 0d |  |
| 30 | 3.3 | SVEC - WR communication protocol on Tx and Rx side |  | 30d | 2016-04-28 | 2016-06-08 | 29 | 0d |  |
| 31 | 3.4 | Tests with WR |  | 8w | 2016-06-09 | 2016-08-24 | 30 | 0d |  |
| 32 | 4 | **Prototype phase** |  | 67d | 2016-04-18 | 2016-08-10 |  | 10d |  |
| 33 | 4.1 | Launch production of PCB prototypes | milestone | 0d | 2016-06-01 | 2016-06-01 | 26 | 10d | 0d |
| 34 | 4.2 | PCB being produced by third party |  | 4w | 2016-06-02 | 2016-06-29 | 33 | 10d | 0d |
| 35 | 4.3 | PCBs received by design office | milestone | 0d | 2016-06-29 | 2016-06-29 | 34 | 10d | 0d |
| 36 | 4.4 | Send components to design office | milestone | 0d | 2016-04-18 | 2016-04-18 | 15 | 62d | 52d |
| 37 | 4.5 | PCB assembly at assembly workshop |  | 3w | 2016-06-30 | 2016-08-10 | 35, 36 | 10d | 0d |
| 38 | 4.6 | First prototype received | milestone | 0d | 2016-08-10 | 2016-08-10 | 37 | 10d |  |
| 39 | 5 | **Testing phase** |  | 125d | 2016-06-02 | 2016-12-21 |  | 45d |  |
| 40 | 5.1 | PTS development including tools |  | 16w | 2016-06-02 | 2016-10-19 | 26 | 95d |  |
| 41 | 5.2 | Test and debug prototypes (EMC tests ..) |  | 6w | 2016-08-25 | 2016-10-05 | 38, 31 | 0d |  |
| 42 | 5.3 | Test in installation |  | 10w | 2016-10-06 | 2016-12-21 | 41 | 50d |  |
| 43 | 5.4 | Design revision |  | 4w | 2016-10-06 | 2016-11-09 | 41 | 0d |  |
| 44 | 6 | **Production phase** |  | 80d | 2016-11-10 | 2017-03-01 |  | 0d |  |
| 45 | 6.1 | Launch production of V2 (tasks 22,24,28,29,30,31,32,33) |  | 16w | 2016-11-10 | 2017-03-01 | 43 | 0d |  |
